# RUP Project Plan

Schedule from MS Project, 2008-10-20 to 2009-06-19, A marks actual dates.
Sapient for NCI/caCORE

## Calendars

- Standard: Mon-Fri 08:00-12:00, 13:00-17:00; Sat-Sun off. Exceptions (off unless hours are given): 2008-11-27, 2008-12-25, 2009-01-01.

## Resources

| Resource |
| --- |
| Team |
| QA |
| Systems |
| Tom |
| Traci |
| Johnita |
| Jason |
| Satya |
| Scott |
| Shalini |
| Kevin |
| Craig |
| Tracy |
| Steve |
| Mayo/NCI |
| Eddie |
| Systems Team |
| C |
| Scott/Craig |
| Scott/Kevin |
| NCI |
| Mike |
| Web App |
| Marilyn |
| Tech Writer |
| Criag |
| VKC |
| Rick |
| Craig/Kevin |
| Harold |
| Raghu |
| Stev |
| Security |
| Frank |

## Schedule

| ID | WBS | Task | Type | Duration | Start | Finish | Predecessors | Complete | Remaining | Total slack | Constraint | Deadline | Resources | Work | Actual work | Text12 |
| --- | --- | --- | --- | --- | --- | --- | --- | --- | --- | --- | --- | --- | --- | --- | --- | --- |
| 1 | 1 | **Inception** |  | 0d | 2008-10-20 A | 2008-10-20 A |  | 100% |  |  |  | 2008-07-26 |  |  |  |  |
| 2 | 1.1 | **Requirements** |  | 0d | 2008-10-20 A | 2008-10-20 A |  | 100% |  |  |  |  |  |  |  |  |
| 3 | 1.1.1 | Define requirements | milestone | 0d | 2008-10-20 A | 2008-10-20 A |  | 100% |  |  |  |  | Tom |  |  |  |
| 4 | 1.1.2 | Review requirements | milestone | 0d | 2008-10-20 A | 2008-10-20 A |  | 100% |  |  |  |  | Tom |  |  |  |
| 5 | 1.1.3 | Complete requirements | milestone | 0d | 2008-10-20 A | 2008-10-20 A |  | 100% |  |  |  |  | Tom |  |  |  |
| 6 | 2 | **Elaboration** |  | 18d | 2008-10-20 A | 2008-11-12 A |  | 100% |  |  |  |  |  | 160h | 160h |  |
| 7 | 2.1 | **Scope Definition** |  | 10d | 2008-10-30 A | 2008-11-12 A |  | 100% |  |  |  |  |  | 80h | 80h |  |
| 8 | 2.1.1 | Draft Scope Wiki |  | 2d | 2008-10-30 A | 2008-10-31 A |  | 100% |  |  | start no earlier than 2008-10-30 |  | Traci | 16h | 16h |  |
| 9 | 2.1.2 | Review Scope |  | 2d | 2008-11-03 A | 2008-11-04 A | 8 | 100% |  |  |  |  | Johnita; Jason | 32h | 32h |  |
| 10 | 2.1.3 | Finalize Scope |  | 4d | 2008-11-05 A | 2008-11-10 A | 9 | 100% |  |  |  |  | Traci | 32h | 32h |  |
| 11 | 2.1.4 | Obtain signoff from Frank of 5.0 Scope |  | 1d | 2008-11-12 A | 2008-11-12 A | 10 | 100% |  |  | start no earlier than 2008-11-12 |  |  |  |  |  |
| 12 | 2.2 | **Project Management** |  | 13d | 2008-10-20 A | 2008-11-05 A |  | 100% |  |  |  |  |  | 80h | 80h |  |
| 13 | 2.2.1 | Draft task plan |  | 2w | 2008-10-20 A | 2008-11-05 A |  | 100% |  |  |  |  | Traci | 80h | 80h | 17507 |
| 14 | 3 | **Construction** |  | 172d | 2008-10-20 A | 2009-06-19 |  | 99% | 1.92d | 0d |  |  |  | 3996.33h | 3910.33h |  |
| 15 | 3.1 | **Gforge Items (code & junit)** |  | 67d | 2008-11-10 A | 2009-02-13 A |  | 100% |  |  |  |  |  | 369h | 369h |  |
| 16 | 3.1.1 | Implement getAssociation for EVS API web service |  | 2w | 2008-11-10 A | 2008-11-21 A |  | 100% |  |  | start no earlier than 2008-11-10 |  | Kevin [50%] | 40h | 40h | 15091 |
| 17 | 3.1.2 | Remove convenience methods for nameToCode |  | 1d | 2008-11-17 A | 2008-11-17 A |  | 100% |  |  | start no earlier than 2008-11-17 |  | Satya [50%] | 4h | 4h | 15222 |
| 18 | 3.1.3 | Two constructors create ConceptReferenceList methods throw exceptions |  | 1w | 2008-11-10 A | 2008-11-14 A |  | 100% |  |  | start no earlier than 2008-11-10 |  | Scott [20%] | 8h | 8h | 15976 |
| 19 | 3.1.4 | Example to dump/query auxiliary metadata |  | 5d | 2008-12-01 A | 2008-12-05 A |  | 100% |  |  | finish no earlier than 2008-12-05 |  | Craig | 40h | 40h | 16508 |
| 20 | 3.1.5 | Better error handling for invalid search criteria in http interface |  | 1w | 2009-02-02 A | 2009-02-06 A |  | 100% |  |  | start no earlier than 2009-02-02 |  | Kevin | 40h | 40h | 16579 |
| 21 | 3.1.6 | javadocs open in new window |  | 2d | 2009-01-08 A | 2009-01-09 A | 19 | 100% |  |  | start no earlier than 2009-01-08 |  | Craig | 16h | 16h | 16686 |
| 22 | 3.1.7 | Import RRF Representation of Relationship Groups |  | 1w | 2009-01-05 A | 2009-01-09 A |  | 100% |  |  | start no earlier than 2008-11-28 |  | Scott | 16h | 16h | 17019 |
| 23 | 3.1.8 | Users should have the ability to request that Search Results be sorted |  | 1w | 2009-02-09 A | 2009-02-13 A | 20 | 100% |  |  |  |  | Tracy | 40h | 40h | 17161 |
| 24 | 3.1.9 | CodingSchemeId not present in exported LexGrid XML |  | 2d | 2008-12-18 A | 2008-12-19 A |  | 100% |  |  | start no earlier than 2008-12-18 |  | Tom | 16h | 16h | 17183 |
| 25 | 3.1.10 | Remove JUnit test dependency on 'Automobiles' vocab for LexEVS Grid Services |  | 2w | 2008-12-05 A | 2008-12-31 A | 24 | 100% |  |  |  |  | Shalini | 80h | 80h | 17405 |
| 26 | 3.1.11 | Change -nf option to -fe (fail on error) |  | 1d | 2008-12-19 A | 2008-12-19 A | 25 | 100% |  |  |  |  | Scott | 8h | 8h | 17410 |
| 27 | 3.1.12 | EntityDescription not assigned to the NCI PT (rdfs:label) using Scrubber output |  | 1w | 2008-12-01 A | 2008-12-05 A | 17 | 100% |  |  |  |  | Satya [50%] | 20h | 20h | 17421 |
| 28 | 3.1.13 | Issue with loading NCI Metathesaurus |  | 2.5d | 2009-01-29 A | 2009-02-04 A |  | 100% |  |  | start no earlier than 2009-01-29 |  | Kevin; Mike | 40h | 40h |  |
| 29 | 3.1.14 | Update LexEVS 4.2 Grid service User Guide |  | 1h | 2009-01-28 A | 2009-01-28 A |  | 100% |  |  | start no earlier than 2009-01-28 |  | Kevin | 1h | 1h | 18641 |

| ID | WBS | Task | Type | Duration | Start | Finish | Predecessors | Complete | Constraint | Resources | Work | Actual work | Text12 |
| --- | --- | --- | --- | --- | --- | --- | --- | --- | --- | --- | --- | --- | --- |
| 30 | 3.2 | **BDA** |  | 98d | 2008-12-15 A | 2009-05-01 A |  | 100% |  |  | 267h | 267h | 17508 |
| 31 | 3.2.1 | Database validation |  | 5d | 2008-12-15 A | 2008-12-19 A |  | 100% | start no earlier than 2008-12-15 | Scott | 40h | 40h |  |
| 32 | 3.2.2 | Establish CI environment (working here) |  | 1d | 2009-02-06 A | 2009-02-06 A |  | 100% | start no earlier than 2009-02-06 | Scott | 8h | 8h |  |
| 33 | 3.2.3 | Verify code quality & junits in CI environment (TBD if needed) |  | 1d | 2009-01-09 A | 2009-01-09 A |  | 100% | start no earlier than 2009-01-09 | Scott | 8h | 8h |  |
| 34 | 3.2.4 | Meet with Systems & BDA |  | 1h | 2009-01-30 A | 2009-01-30 A |  | 100% | start no earlier than 2009-01-30 | Scott/Craig | 1h | 1h |  |
| 35 | 3.2.5 | Evaluate code for extraneous classes |  | 0.5d | 2009-01-12 A | 2009-01-12 A |  | 100% | start no earlier than 2009-01-12 | Scott | 4h | 4h |  |
| 36 | 3.2.6 | Remove code & develop build script |  | 5d | 2009-01-12 A | 2009-01-19 A | 35 | 100% |  | Scott | 40h | 40h |  |
| 37 | 3.2.7 | BDA deployment of Data services |  | 1d | 2009-01-19 A | 2009-01-20 A | 36 | 100% |  | Scott/Kevin | 8h | 8h |  |
| 38 | 3.2.8 | Rewrite XML due to file structure changes |  | 4d | 2009-01-27 A | 2009-01-30 A | 37 | 100% | start no earlier than 2009-01-27 | Scott | 32h | 32h |  |
| 39 | 3.2.9 | **Verify build & deploy process works** |  | 2d | 2009-02-02 A | 2009-02-03 A | 38 | 100% |  |  | 16h | 16h |  |
| 40 | 3.2.9.1 | Local test |  | 2d | 2009-02-02 A | 2009-02-03 A |  | 100% | start no earlier than 2009-01-29 | Scott | 16h | 16h |  |
| 41 | 3.2.10 | Multidatabase Junit run tasks |  | 2d | 2009-02-04 A | 2009-02-05 A | 39 | 100% |  | Scott | 16h | 16h |  |
| 42 | 3.2.11 | **Dry run of BDA process** |  | 63d | 2009-02-04 A | 2009-05-01 A | 39 | 100% |  |  | 93h | 93h |  |
| 43 | 3.2.11.1 | Request for Anthill Pro access (2 new projects) |  | 1h | 2009-02-04 A | 2009-02-04 A |  | 100% |  | Scott | 1h | 1h |  |
| 44 | 3.2.11.2 | Receive Anthill pro access | milestone | 0d | 2009-02-20 A | 2009-02-20 A |  | 100% | start no earlier than 2009-02-20 | Web App |  |  |  |
| 45 | 3.2.11.3 | Deploy via BDA process to NCI Dev |  | 1d | 2009-03-04 A | 2009-03-04 A |  | 100% | start no earlier than 2009-03-04 | Scott | 8h | 8h |  |
| 46 | 3.2.11.4 | Deploy via BDA process in QA |  | 2d | 2009-03-16 A | 2009-03-17 A |  | 100% |  | Scott | 16h | 16h |  |
| 47 | 3.2.11.5 | Create DRT deployment request for Dry Run to Stage |  | 2h | 2009-04-09 A | 2009-04-09 A | 46FS+2w | 100% | start no earlier than 2009-04-09 | Scott | 2h | 2h |  |
| 48 | 3.2.11.6 | BDA Dry Run in Stage |  | 4d | 2009-04-09 A | 2009-04-15 A | 47 | 100% |  | Systems | 32h | 32h |  |
| 49 | 3.2.11.7 | Create DRT deployment request for Dry Run to Production |  | 2h | 2009-04-22 A | 2009-04-22 A | 48FS+1w | 100% |  | Scott | 2h | 2h |  |
| 50 | 3.2.11.8 | BDA Dry Run in Prod |  | 4d | 2009-04-28 A | 2009-05-01 A | 49 | 100% | start no earlier than 2009-04-28 | Systems | 32h | 32h |  |
| 51 | 3.2.12 | Request Stage & Prod Anthill Pro setup |  | 1h | 2009-03-02 A | 2009-03-02 A |  | 100% | start no earlier than 2009-03-02 | Scott | 1h | 1h |  |
| 52 | 3.3 | **Data Services - SDK** |  | 77d | 2008-10-20 A | 2009-02-06 A |  | 100% |  |  | 635.93h | 635.93h | 17511 |
| 53 | 3.3.1 | **Create LexEVS caCORE generated system** |  | 77d | 2008-10-20 A | 2009-02-06 A |  | 100% |  |  | 278.73h | 278.73h |  |
| 54 | 3.3.1.1 | Create Hibernate Database mappings |  | 77d | 2008-10-20 A | 2009-02-06 A |  | 100% | start no earlier than 2008-10-20 | Kevin [25%] | 155.95h | 155.95h |  |
| 55 | 3.3.1.2 | Enable Security |  | 77d | 2008-10-20 A | 2009-02-06 A |  | 100% | start no earlier than 2008-10-20 | Kevin [10%] | 61.6h | 61.6h |  |
| 56 | 3.3.1.3 | Enable multi database and singe database support |  | 76d | 2008-10-20 A | 2009-02-05 A |  | 100% | start no earlier than 2008-10-20 | Kevin [5%] | 30.78h | 30.78h |  |
| 57 | 3.3.1.4 | Testing |  | 76d | 2008-10-20 A | 2009-02-05 A |  | 100% | start no earlier than 2008-10-20 | Kevin [5%] | 30.4h | 30.4h |  |

Notes:
- 33: dependent on NCI BDA team fixing the CI environment.

| ID | WBS | Task | Duration | Start | Finish | Predecessors | Complete | Remaining | Total slack | Constraint | Resources | Work | Actual work | Text12 |
| --- | --- | --- | --- | --- | --- | --- | --- | --- | --- | --- | --- | --- | --- | --- |
| 58 | 3.3.2 | **Create LexEVS Grid Data Service** | 77d | 2008-10-20 A | 2009-02-06 A |  | 100% |  |  |  |  | 277.2h | 277.2h |  |
| 59 | 3.3.2.1 | Generate Service with Introduce | 77d | 2008-10-20 A | 2009-02-06 A |  | 100% |  |  | start no earlier than 2008-10-20 | Kevin [40%] | 246.4h | 246.4h |  |
| 60 | 3.3.2.2 | Testing | 77d | 2008-10-20 A | 2009-02-06 A |  | 100% |  |  | start no earlier than 2008-10-20 | Kevin [5%] | 30.8h | 30.8h |  |
| 61 | 3.3.3 | **SDK Bug Fix** | 10d | 2008-12-11 A | 2008-12-24 A |  | 100% |  |  |  |  | 80h | 80h |  |
| 62 | 3.3.3.1 | HQL translator redesign | 2w | 2008-12-11 A | 2008-12-24 A |  | 100% |  |  | start no earlier than 2008-12-11 | Kevin | 80h | 80h | 17729 |
| 63 | 3.4 | **Model updates for Silver/Gold Compatibility** | 124d | 2008-12-29 A | 2009-06-19 |  | 89% | 13.87d | 0d |  |  | 650h | 564h | 17509 |
| 64 | 3.4.1 | Model changes and deliver XSDs | 1w | 2008-12-29 A | 2009-01-05 A |  | 100% |  |  | start no earlier than 2008-12-29 | Scott | 40h | 40h |  |
| 65 | 3.4.2 | **Annotations** | 105d | 2009-01-19 A | 2009-06-12 |  | 93% | 7.01d | 5d |  |  | 570h | 524h |  |
| 66 | 3.4.2.1 | 1st annotations to NCI | 2w | 2009-01-19 A | 2009-01-30 A |  | 100% |  |  | start no earlier than 2009-01-19 | Scott [50%] | 40h | 40h |  |
| 67 | 3.4.2.2 | Annotation review at NCI | 4w | 2009-02-02 A | 2009-02-27 A | 66 | 100% |  |  |  | NCI | 160h | 160h |  |
| 68 | 3.4.2.3 | Updates to 5.0 model & annotation review | 4w | 2009-03-17 A | 2009-04-24 A | 70FS+2w | 100% |  |  |  | Scott | 160h | 160h |  |
| 69 | 3.4.2.4 | Silver Level Review meetings | 1h | 2009-01-29 A | 2009-01-29 A |  | 100% |  |  | start no earlier than 2009-01-29 | Scott; Kevin | 2h | 2h |  |
| 70 | 3.4.2.5 | Silver level review changes | 1w | 2009-03-10 A | 2009-03-16 A |  | 100% |  |  | start no earlier than 2009-03-10 | Scott | 40h | 40h |  |
| 71 | 3.4.2.6 | Review/modify 2.3 submission changes requested | 15d | 2009-04-13 A | 2009-05-01 |  | 95% | 0.75d | 35d | finish no earlier than 2009-05-01 | Scott | 120h | 114h |  |
| 72 | 3.4.2.7 | Submit 5.0 changes to NCI | 1d | 2009-05-19 A | 2009-05-19 A | 68 | 100% |  |  | start no earlier than 2009-05-04 | Scott | 8h | 8h |  |
| 73 | 3.4.2.8 | NCI review | 2w | 2009-05-20 A | 2009-06-02 A | 72 | 100% |  |  |  |  |  |  |  |
| 74 | 3.4.2.9 | Pull together documentation for 5.0 submission | 1w | 2009-06-08 | 2009-06-12 | 73 |  |  | 0d | start no earlier than 2009-06-08 | Scott | 40h |  |  |
| 75 | 3.4.3 | Submit final 5.0 package for Silver Level review | 1w | 2009-06-15 | 2009-06-19 | 74 |  |  | 0d |  | Scott | 40h |  |  |
| 76 | 3.5 | **Unified OWL Loader** | 73.5d | 2008-10-20 A | 2009-02-03 A |  | 100% |  |  |  |  | 438.4h | 438.4h | 17233 |
| 77 | 3.5.1 | **Improve OWL Model footprint** | 22d | 2008-10-20 A | 2008-11-18 A |  | 100% |  |  |  |  | 96.8h | 96.8h |  |
| 78 | 3.5.1.1 | **Upgrade to Protégé 3.4** | 15d | 2008-10-20 A | 2008-11-07 A |  | 100% |  |  |  |  | 66h | 66h |  |
| 79 | 3.5.1.1.1 | Integrate Protégé 3.4 jars into LexBIG | 1d | 2008-10-20 A | 2008-10-20 A |  | 100% |  |  |  | Craig [5%]; Satya [50%] | 4.4h | 4.4h |  |
| 80 | 3.5.1.1.2 | Identify and fix artifacts appearing after upgrade | 2w | 2008-10-21 A | 2008-11-03 A | 79 | 100% |  |  |  | Craig [5%]; Satya [50%] | 44h | 44h |  |
| 81 | 3.5.1.1.3 | Final verification of LexBIG using updated jars | 2d | 2008-11-04 A | 2008-11-05 A | 80 | 100% |  |  |  | Craig [5%]; Satya [50%] | 8.8h | 8.8h |  |
| 82 | 3.5.1.1.4 | Profile and report on improvement | 2d | 2008-11-06 A | 2008-11-07 A | 81 | 100% |  |  |  | Craig [5%]; Satya [50%] | 8.8h | 8.8h |  |

| ID | WBS | Task | Type | Duration | Start | Finish | Predecessors | Complete | Constraint | Resources | Work | Actual work | Text12 |
| --- | --- | --- | --- | --- | --- | --- | --- | --- | --- | --- | --- | --- | --- |
| 83 | 3.5.1.2 | **Protégé DB support** |  | 7d | 2008-11-10 A | 2008-11-18 A |  | 100% |  |  | 30.8h | 30.8h |  |
| 84 | 3.5.1.2.1 | Turn on Protégé DB support |  | 2d | 2008-11-10 A | 2008-11-11 A | 82 | 100% |  | Craig [5%]; Satya [50%] | 8.8h | 8.8h |  |
| 85 | 3.5.1.2.2 | Profile and report on memory improvement |  | 1w | 2008-11-12 A | 2008-11-18 A | 84 | 100% |  | Craig [5%]; Satya [50%] | 22h | 22h |  |
| 86 | 3.5.2 | **Converge NCIT functionality to generic loader** |  | 27d | 2008-11-19 A | 2008-12-29 A | 77 | 100% |  |  | 118.8h | 118.8h |  |
| 87 | 3.5.2.1 | **Add support for NCI based complex props** |  | 10d | 2008-11-19 A | 2008-12-03 A |  | 100% |  |  | 44h | 44h |  |
| 88 | 3.5.2.1.1 | Implement and test |  | 2w | 2008-11-19 A | 2008-12-03 A |  | 100% |  | Craig [5%]; Satya [50%] | 44h | 44h |  |
| 89 | 3.5.2.2 | **Add support for loader preferences and manifest** |  | 5d | 2008-12-04 A | 2008-12-10 A | 87 | 100% |  |  | 22h | 22h |  |
| 90 | 3.5.2.2.1 | Implement and test |  | 1w | 2008-12-04 A | 2008-12-10 A |  | 100% |  | Craig [5%]; Satya [50%] | 22h | 22h |  |
| 91 | 3.5.2.3 | **Add support to split role and associations** |  | 12d | 2008-12-11 A | 2008-12-29 A | 89 | 100% |  |  | 52.8h | 52.8h |  |
| 92 | 3.5.2.3.1 | Investigate |  | 2d | 2008-12-11 A | 2008-12-12 A |  | 100% |  | Craig [5%]; Satya [50%] | 8.8h | 8.8h |  |
| 93 | 3.5.2.3.2 | Implement and test |  | 2w | 2008-12-15 A | 2008-12-29 A | 92 | 100% |  | Craig [5%]; Satya [50%] | 44h | 44h |  |
| 94 | 3.5.3 | **Improve LexGrid model footprint** |  | 27d | 2008-12-08 A | 2009-01-15 A |  | 100% |  |  | 162.8h | 162.8h |  |
| 95 | 3.5.3.1 | Research SDK generated write API |  | 1w | 2008-12-08 A | 2008-12-12 A |  | 100% |  | Craig [5%]; Satya [50%] | 22h | 22h |  |
| 96 | 3.5.3.2 | Research emf caching |  | 1w | 2008-12-08 A | 2008-12-12 A | 95SS | 100% |  | Craig [5%]; Satya [50%] | 22h | 22h |  |
| 97 | 3.5.3.3 | Review options/decide which option to consider |  | 1w | 2008-12-08 A | 2008-12-12 A | 96SS | 100% |  | Craig [5%]; Satya [50%] | 22h | 22h |  |
| 98 | 3.5.3.4 | Implement and test selected option |  | 3.4w | 2008-12-15 A | 2009-01-08 A | 97 | 100% | finish no earlier than 2009-01-08 | Craig [5%]; Satya [50%] | 74.8h | 74.8h |  |
| 99 | 3.5.3.5 | Profile and report on improvement |  | 1w | 2009-01-09 A | 2009-01-15 A | 98 | 100% | finish no earlier than 2009-01-15 | Craig [5%]; Satya [50%] | 22h | 22h |  |
| 100 | 3.5.4 | Testing & bug fixes for OWL |  | 1.5w | 2009-01-23 A | 2009-02-03 A | 94FS+1w | 100% |  | Tom | 60h | 60h |  |
| 101 | 3.6 | **Support** |  | 0d | 2008-10-20 A | 2008-10-20 A |  | 100% |  |  |  |  |  |
| 102 | 3.6.1 | **caDSR** |  | 0d | 2008-10-20 A | 2008-10-20 A |  | 100% |  |  |  |  |  |
| 103 | 3.6.1.1 | Determine support needs/requirements | milestone | 0d | 2008-10-20 A | 2008-10-20 A |  | 100% |  | Craig [10%] |  |  |  |
| 104 | 3.6.2 | **MDR** |  | 0d | 2008-10-20 A | 2008-10-20 A |  | 100% |  |  |  |  |  |
| 105 | 3.6.2.1 | Determine support needs/requirements | milestone | 0w | 2008-10-20 A | 2008-10-20 A |  | 100% |  | Craig [10%] |  |  |  |
| 106 | 3.7 | **Migration Guide/Documentation** |  | 105d | 2008-12-15 A | 2009-05-12 A |  | 100% |  |  | 962h | 962h | 17510 |
| 107 | 3.7.1 | Gather requirements for migration |  | 6w | 2008-12-22 A | 2009-02-26 A | 23 | 100% |  | Craig [20%] | 48h | 48h |  |
| 108 | 3.7.2 | Meet with VKC regaring LexEVS training materials |  | 1d | 2008-12-15 A | 2008-12-15 A | 107 | 100% |  | Craig | 8h | 8h |  |
| 109 | 3.7.3 | Meet with VKC for additional planning |  | 1h | 2009-03-03 A | 2009-03-03 A |  | 100% | start no earlier than 2009-03-03 | Traci; Criag | 2h | 2h |  |

Notes:
- 103: Per Johnita, nothing more at this time and probably won't have new requirements until after 5.0 is released. - 12/15/08
- 105: Per Johnita, nothing more at this time and probably won't have new requirements until after 5.0 is released. - 12/15/08

| ID | WBS | Task | Type | Duration | Start | Finish | Predecessors | Complete | Constraint | Resources | Work | Actual work | Text12 |
| --- | --- | --- | --- | --- | --- | --- | --- | --- | --- | --- | --- | --- | --- |
| 110 | 3.7.4 | **Develop migration materials** |  | 35d | 2009-03-16 A | 2009-05-01 A | 107 | 100% |  |  | 792h | 792h |  |
| 111 | 3.7.4.1 | Develop outline |  | 2w | 2009-03-24 A | 2009-04-06 A |  | 100% |  | VKC | 80h | 80h |  |
| 112 | 3.7.4.2 | Review outline |  | 1d | 2009-04-10 A | 2009-04-10 A |  | 100% |  | Craig; Traci | 16h | 16h |  |
| 113 | 3.7.4.3 | VKC migration of content to Wiki |  | 1w | 2009-04-13 A | 2009-04-17 A | 112 | 100% |  | VKC | 40h | 40h |  |
| 114 | 3.7.4.4 | **EVS API Tech/Admin Guide** |  | 25.5d | 2009-03-16 A | 2009-04-20 A |  | 100% |  |  | 332h | 332h | 17521 |
| 115 | 3.7.4.4.1 | Obtain EVS API tech guide source documents |  | 1w | 2009-03-16 A | 2009-03-20 A | 109 | 100% |  | Traci | 40h | 40h |  |
| 116 | 3.7.4.4.2 | Update EVS API Tech/Admin Guide |  | 3w | 2009-03-23 A | 2009-04-10 A | 115 | 100% |  | Kevin | 120h | 120h |  |
| 117 | 3.7.4.4.3 | Create Migration document |  | 4.3w | 2009-03-20 A | 2009-04-20 A | 115 | 100% |  | Craig | 172h | 172h |  |
| 118 | 3.7.4.5 | **Update Wiki** |  | 10d | 2009-04-20 A | 2009-05-01 A |  | 100% |  |  | 324h | 324h |  |
| 119 | 3.7.4.5.1 | Update Wiki with migration documentation |  | 3d | 2009-04-20 A | 2009-04-23 A | 117 | 100% |  | Craig | 24h | 24h |  |
| 120 | 3.7.4.5.2 | Update LexBIG programmer/admin guide information |  | 1.5w | 2009-04-22 A | 2009-05-01 A | 157 | 100% | start no earlier than 2009-04-22 | Craig/Kevin | 60h | 60h |  |
| 121 | 3.7.4.5.3 | Update LexBIG Install guide information |  | 1.5w | 2009-04-22 A | 2009-05-01 A | 120SS | 100% |  | Scott | 60h | 60h |  |
| 122 | 3.7.4.5.4 | Update LexEVS Grid Data/Analytical Service (programmer guide) info |  | 1.5w | 2009-04-20 A | 2009-04-29 A | 120SS | 100% | start no earlier than 2009-04-06 | Kevin | 60h | 60h |  |
| 123 | 3.7.4.5.5 | Update mapping document |  | 1w | 2009-04-20 A | 2009-04-24 A | 113 | 100% | start no earlier than 2009-04-06 | Rick | 40h | 40h |  |
| 124 | 3.7.4.5.6 | Update model info on Wiki |  | 2w | 2009-04-20 A | 2009-05-01 A |  | 100% | start no earlier than 2009-04-20 | Craig | 80h | 80h |  |
| 125 | 3.7.5 | Review documentation on Wiki |  | 1w | 2009-05-04 A | 2009-05-08 A | 110 | 100% |  | Traci; Craig | 80h | 80h |  |
| 126 | 3.7.6 | Work with VKC to update all on VKC site |  | 2d | 2009-05-11 A | 2009-05-12 A | 125 | 100% |  | Traci; Craig | 32h | 32h |  |
| 127 | 3.8 | **Testing** |  | 61d | 2009-02-04 A | 2009-04-29 A |  | 100% |  |  | 674h | 674h |  |
| 128 | 3.8.1 | Request Jboss containers (2) |  | 1h | 2009-02-04 A | 2009-02-04 A |  | 100% | start no earlier than 2009-02-09 | Craig | 1h | 1h |  |
| 129 | 3.8.2 | Receive Jboss containers | milestone | 0d | 2009-02-25 A | 2009-02-25 A |  | 100% | start no earlier than 2009-02-27 | Systems |  |  |  |
| 130 | 3.8.3 | Receive URLS |  | 2d | 2009-03-05 A | 2009-03-06 A |  | 100% |  | Systems | 16h | 16h |  |
| 131 | 3.8.4 | Create 5.0 build |  | 1d | 2009-02-06 A | 2009-02-06 A |  | 100% | must finish on 2009-02-06 | Kevin | 8h | 8h |  |
| 132 | 3.8.5 | Mayo Dev testing (LexBig, distributed, data services, grid junits) |  | 1w | 2009-02-09 A | 2009-02-13 A | 131 | 100% |  | Kevin | 40h | 40h |  |
| 133 | 3.8.6 | Request EVS API URLs from Systems Team for tier level services |  | 1h | 2009-02-09 A | 2009-02-09 A |  | 100% |  | Craig | 1h | 1h |  |
| 134 | 3.8.7 | Request Grid URLs from Systems Team for tier level services |  | 1h | 2009-02-09 A | 2009-02-09 A |  | 100% |  | Craig | 1h | 1h |  |
| 135 | 3.8.8 | Meeting w/QA Mgr & Systems for deployment (ARC) |  | 2h | 2009-02-16 A | 2009-02-16 A | 134 | 100% |  | Mayo/NCI | 2h | 2h |  |
| 136 | 3.8.9 | Update home.jsp |  | 1h | 2009-02-16 A | 2009-02-16 A | 135 | 100% |  | Craig | 1h | 1h |  |

| ID | WBS | Task | Type | Duration | Start | Finish | Predecessors | Complete | Constraint | Resources | Work | Actual work | Text12 |
| --- | --- | --- | --- | --- | --- | --- | --- | --- | --- | --- | --- | --- | --- |
| 137 | 3.8.10 | **Dev** |  | 25.5d | 2009-02-17 A | 2009-03-24 A |  | 100% |  |  | 336h | 336h |  |
| 138 | 3.8.10.1 | Promote to NCI Dev (Tracy's tiers) |  | 1d | 2009-02-23 A | 2009-02-23 A |  | 100% | start no earlier than 2009-02-23 | Scott; Tracy | 16h | 16h | 17502 |
| 139 | 3.8.10.2 | Execute Test cases (Distributed, Grid, Data junits) |  | 2d | 2009-02-24 A | 2009-02-25 A | 138 | 100% |  | Shalini | 16h | 16h |  |
| 140 | 3.8.10.3 | Load Content |  | 1w | 2009-02-17 A | 2009-02-23 A |  | 100% | start no earlier than 2009-02-17 | Tracy | 40h | 40h |  |
| 141 | 3.8.10.4 | Redeploy to Actual 5.0 Dev |  | 1d | 2009-02-25 A | 2009-02-25 A | 129 | 100% |  | Scott | 8h | 8h |  |
| 142 | 3.8.10.5 | Execute Test cases (Distributed, Grid, Data junits) |  | 4d | 2009-02-24 A | 2009-02-27 A |  | 100% |  | Shalini | 32h | 32h |  |
| 143 | 3.8.10.6 | Bug fixes |  | 5d | 2009-03-02 A | 2009-03-06 A | 142 | 100% |  | Team | 40h | 40h |  |
| 144 | 3.8.10.7 | 2nd deployment to Dev |  | 0.5d | 2009-03-09 A | 2009-03-09 A | 143 | 100% |  | Scott; Kevin | 8h | 8h |  |
| 145 | 3.8.10.8 | 2nd load of content |  | 2w | 2009-03-09 A | 2009-03-23 A | 144 | 100% |  | Tracy | 80h | 80h |  |
| 146 | 3.8.10.9 | Re-execute test cases (Distributed, Grid, Data junits) |  | 2.2w | 2009-03-09 A | 2009-03-24 A | 144 | 100% |  | Kevin | 88h | 88h |  |
| 147 | 3.8.10.10 | Promote content to QA |  | 1d | 2009-03-23 A | 2009-03-24 A | 145 | 100% |  | Tracy | 8h | 8h |  |
| 148 | 3.8.11 | **QA** |  | 29d | 2009-03-06 A | 2009-04-15 A |  | 100% |  |  | 181h | 181h |  |
| 149 | 3.8.11.1 | Receive Jboss containers & URLS from Systems Team | milestone | 0d | 2009-03-06 A | 2009-03-06 A |  | 100% | start no earlier than 2009-03-06 |  |  |  |  |
| 150 | 3.8.11.2 | Create QA tag in SVN |  | 1h | 2009-03-20 A | 2009-03-20 A | 137 | 100% |  | Scott | 1h | 1h |  |
| 151 | 3.8.11.3 | draft deployment request for Steve |  | 2h | 2009-03-24 A | 2009-03-24 A | 146 | 100% |  | Scott | 2h | 2h |  |
| 152 | 3.8.11.4 | Promote to QA |  | 0.5d | 2009-03-24 A | 2009-03-24 A | 146 | 100% |  | Steve | 4h | 4h | 17503 |
| 153 | 3.8.11.5 | Execute Test cases |  | 1w | 2009-03-25 A | 2009-03-31 A | 152 | 100% |  | Steve | 40h | 40h |  |
| 154 | 3.8.11.6 | Request & schedule AppScan |  | 2h | 2009-03-25 A | 2009-03-25 A | 152 | 100% |  | Kevin | 2h | 2h |  |
| 155 | 3.8.11.7 | Execution of AppScan complete | milestone | 0d | 2009-04-06 A | 2009-04-06 A | 154FS+4d | 100% | start no earlier than 2009-04-06 | Systems |  |  |  |
| 156 | 3.8.11.8 | Bug fixes |  | 1w | 2009-04-01 A | 2009-04-07 A | 153 | 100% |  | Scott; Kevin | 80h | 80h |  |
| 157 | 3.8.11.9 | Update deployment request for redeploy |  | 0.5d | 2009-04-07 A | 2009-04-07 A | 156FF | 100% |  | Craig | 4h | 4h |  |
| 158 | 3.8.11.10 | Re-deploy to QA with fixes |  | 2d | 2009-04-08 A | 2009-04-09 A | 157 | 100% |  | Steve | 16h | 16h |  |
| 159 | 3.8.11.11 | Re-execute test cases |  | 4d | 2009-04-10 A | 2009-04-15 A | 158 | 100% |  | Steve | 32h | 32h |  |
| 160 | 3.8.12 | **Stage** |  | 23d | 2009-03-30 A | 2009-04-29 A |  | 100% |  |  | 87h | 87h |  |
| 161 | 3.8.12.1 | Receive Jboss containers & URLS from Systems Team | milestone | 0d | 2009-03-30 A | 2009-03-30 A |  | 100% | start no earlier than 2009-03-30 |  |  |  |  |
| 162 | 3.8.12.2 | Create Stage tag in SVN |  | 1h | 2009-04-16 A | 2009-04-16 A | 148 | 100% |  | Scott | 1h | 1h |  |
| 163 | 3.8.12.3 | Obtain approval to move to Stage |  | 2d | 2009-04-16 A | 2009-04-17 A | 148 | 100% |  | Steve | 16h | 16h |  |
| 164 | 3.8.12.4 | Draft/Submit Deployment Request for Stage (API/Grid/DB) |  | 4h | 2009-04-17 A | 2009-04-17 A | 163FF | 100% |  | Craig | 4h | 4h |  |
| 165 | 3.8.12.5 | Promote to Stage |  | 3d | 2009-04-20 A | 2009-04-22 A | 163 | 100% |  | Systems Team | 24h | 24h | 17504 |
| 166 | 3.8.12.6 | Execute test cases |  | 5d | 2009-04-23 A | 2009-04-29 A | 165 | 100% |  | Steve | 40h | 40h |  |
| 167 | 3.8.12.7 | Request & schedule external AppScan |  | 2h | 2009-04-23 A | 2009-04-23 A | 165 | 100% |  | Scott | 2h | 2h |  |
| 168 | 3.8.12.8 | Execution of AppScan complete | milestone | 0d | 2009-04-27 A | 2009-04-27 A | 167FS+2d | 100% |  | Systems |  |  |  |

| ID | WBS | Task | Type | Duration | Start | Finish | Predecessors | Complete | Constraint | Resources | Work | Actual work | Text12 |
| --- | --- | --- | --- | --- | --- | --- | --- | --- | --- | --- | --- | --- | --- |
| 169 | 4 | **Transition** |  | 23d | 2009-04-13 A | 2009-05-13 A |  | 100% |  |  | 443h | 443h |  |
| 170 | 4.1 | **Documentation** |  | 20d | 2009-04-13 A | 2009-05-08 A | 148SS | 100% |  |  | 318h | 318h |  |
| 171 | 4.1.1 | **Release Notes** |  | 8d | 2009-04-21 A | 2009-04-30 A |  | 100% |  |  | 24h | 24h |  |
| 172 | 4.1.1.1 | Draft Release notes - Wiki |  | 2d | 2009-04-21 A | 2009-04-22 A | 165SS | 100% | start no earlier than 2009-04-21 | Rick | 16h | 16h |  |
| 173 | 4.1.1.2 | Finalize release notes (with Steve & Tracy) |  | 1d | 2009-04-30 A | 2009-04-30 A | 172 | 100% | start no earlier than 2009-04-30 | Craig | 8h | 8h |  |
| 174 | 4.1.1.3 | Completed release notes | milestone | 0d | 2009-04-30 A | 2009-04-30 A | 173 | 100% |  | Craig |  |  | 17520 |
| 175 | 4.1.2 | **Production announcements** |  | 5d | 2009-04-30 A | 2009-05-06 A | 166 | 100% |  |  | 40h | 40h |  |
| 176 | 4.1.2.1 | Draft release announcement |  | 3d | 2009-04-30 A | 2009-05-04 A |  | 100% |  | Raghu | 24h | 24h |  |
| 177 | 4.1.2.2 | Send to Frank for approval |  | 2d | 2009-05-05 A | 2009-05-06 A | 176 | 100% |  | Raghu | 16h | 16h |  |
| 178 | 4.1.3 | **NCICB webpage updates** |  | 7d | 2009-04-30 A | 2009-05-08 A | 160 | 100% |  |  | 152h | 152h |  |
| 179 | 4.1.3.1 | Complete updates |  | 1w | 2009-04-30 A | 2009-05-06 A |  | 100% |  | Tracy | 40h | 40h |  |
| 180 | 4.1.3.2 | **Send through the tiers for deployment** |  | 7d | 2009-04-30 A | 2009-05-08 A |  | 100% |  | Tracy | 112h | 112h |  |
| 181 | 4.1.3.2.1 | Dev |  | 1d | 2009-04-30 A | 2009-04-30 A |  | 100% |  | Tracy | 8h | 8h |  |
| 182 | 4.1.3.2.2 | Stage |  | 3d | 2009-05-01 A | 2009-05-05 A | 181 | 100% |  | Tracy | 24h | 24h |  |
| 183 | 4.1.3.2.3 | Prod |  | 3d | 2009-05-06 A | 2009-05-08 A | 182 | 100% |  | Tracy | 24h | 24h |  |
| 184 | 4.1.4 | **Deploy Website Updates** |  | 19.25d | 2009-04-13 A | 2009-05-08 A |  | 100% |  |  | 102h | 102h |  |
| 185 | 4.1.4.1 | **Dev** |  | 5.25d | 2009-04-13 A | 2009-04-20 A | 137 | 100% |  |  | 42h | 42h |  |
| 186 | 4.1.4.1.1 | Submit ticket through JIRA for Dev |  | 2h | 2009-04-13 A | 2009-04-13 A |  | 100% | start no earlier than 2009-04-13 | Craig | 2h | 2h |  |
| 187 | 4.1.4.1.2 | Deploy to Dev |  | 5d | 2009-04-13 A | 2009-04-20 A | 186 | 100% |  | Systems Team | 40h | 40h |  |
| 188 | 4.1.4.2 | **Stage** |  | 3.25d | 2009-04-22 A | 2009-04-27 A | 163 | 100% |  |  | 26h | 26h |  |
| 189 | 4.1.4.2.1 | Submit ticket through JIRA for Stage |  | 2h | 2009-04-22 A | 2009-04-22 A |  | 100% | start no earlier than 2009-04-22 | Craig | 2h | 2h |  |
| 190 | 4.1.4.2.2 | Deploy to Stage |  | 3d | 2009-04-22 A | 2009-04-27 A | 189 | 100% |  | Systems Team | 24h | 24h |  |
| 191 | 4.1.4.3 | **Prod** |  | 4.25d | 2009-05-04 A | 2009-05-08 A | 196 | 100% |  |  | 34h | 34h |  |
| 192 | 4.1.4.3.1 | Submit ticket through JIRA for Prod |  | 2h | 2009-05-04 A | 2009-05-04 A |  | 100% |  | Craig | 2h | 2h |  |
| 193 | 4.1.4.3.2 | Deploy to Prod |  | 4d | 2009-05-04 A | 2009-05-08 A | 192 | 100% |  | Systems Team | 32h | 32h |  |

| ID | WBS | Task | Type | Duration | Start | Finish | Predecessors | Complete | Constraint | Resources | Work | Actual work | Text12 |
| --- | --- | --- | --- | --- | --- | --- | --- | --- | --- | --- | --- | --- | --- |
| 194 | 4.2 | **Promote to Production** |  | 13d | 2009-04-27 A | 2009-05-13 A |  | 100% |  |  | 125h | 125h |  |
| 195 | 4.2.1 | Receive Jboss containers & URLS | milestone | 0d | 2009-04-27 A | 2009-04-27 A |  | 100% | start no earlier than 2009-04-27 |  |  |  |  |
| 196 | 4.2.2 | Obtain approval to move to Production |  | 2d | 2009-04-30 A | 2009-05-01 A | 166 | 100% | start no earlier than 2009-04-20 | Steve | 16h | 16h |  |
| 197 | 4.2.3 | Production tag in SVN (Use QA tag) |  | 1h | 2009-05-04 A | 2009-05-04 A | 196 | 100% |  | Craig | 1h | 1h |  |
| 198 | 4.2.4 | Draft/Submit Deployment Request (API/Grid/DB) |  | 2h | 2009-05-04 A | 2009-05-04 A | 196 | 100% |  | Steve | 2h | 2h |  |
| 199 | 4.2.5 | Update Gforge | milestone | 0d | 2009-05-06 A | 2009-05-06 A | 198 | 100% | start no earlier than 2009-05-06 | Craig |  |  |  |
| 200 | 4.2.6 | Deploy to Production |  | 4d | 2009-05-04 A | 2009-05-07 A | 196 | 100% |  | Systems | 32h | 32h | 17505 |
| 201 | 4.2.7 | Request & schedule AppScan |  | 2h | 2009-05-06 A | 2009-05-06 A | 200SS+2d | 100% |  | Scott | 2h | 2h |  |
| 202 | 4.2.8 | Execution of external AppScan complete | milestone | 0d | 2009-05-08 A | 2009-05-08 A | 201FS+2d | 100% |  | Systems |  |  |  |
| 203 | 4.2.9 | Firewall exceptions deployed to Prod |  | 6d | 2009-05-06 A | 2009-05-13 A |  | 100% | start no earlier than 2009-05-06 | Systems | 48h | 48h |  |
| 204 | 4.2.10 | 2nd firewall scan and firewall exception request approved |  | 1d | 2009-05-13 A | 2009-05-13 A |  | 100% | start no earlier than 2009-05-13 | Security | 8h | 8h |  |
| 205 | 4.2.11 | Production testing |  | 2d | 2009-05-08 A | 2009-05-11 A | 200 | 100% |  | Steve | 16h | 16h |  |
| 206 | 4.2.12 | Milestone - Production Deployment Complete | milestone | 0d | 2009-05-13 A | 2009-05-13 A | 204 | 100% |  |  |  |  |  |
| 207 | 4.2.13 | Send announcements for 5.0 | milestone | 0h | 2009-05-13 A | 2009-05-13 A | 206 | 100% |  | Frank |  |  |  |
